# Woods Family 3BR Home

Schedule from MS Project, 2016-05-02 to 2017-02-06, costs in $.
Residential Construction
Building with Heart
Clear debris. Two girls. Greene City Interiors for finishing.

## Calendars

- BWH Standard Calendar: Mon-Fri 08:00-12:00, 13:00-17:00; Sat-Sun off. Exceptions (off unless hours are given): 2016-05-30 to 2025-05-26 (Memorial Day, recurring), 2016-07-04 (Independence Day), 2016-09-05 (Labor Day), 2016-11-08 08:00-12:00 (Election Day), 2016-11-24 (Thanksgiving Day), 2016-11-25 (Black Friday), 2016-12-26 (Christmas Day (observed)), 2017-01-02 (New Year's Day (observed)).

## Resources

| Resource | Unit | Rate |
| --- | --- | --- |
| Concrete contractor |  |  |
| Finish carpentry contractor |  |  |
| Fencing contractor |  |  |
| Masonry contractor |  |  |
| General contractor |  |  |
| Architect |  |  |
| Owner |  |  |
| Mortgage lender |  |  |
| Inspector |  |  |
| Electric company |  |  |
| Site excavation contractor |  |  |
| Electric contractor |  |  |
| Plumbing contractor |  |  |
| Framing contractor |  |  |
| Roofing contractor |  |  |
| Heating and AC contractor |  |  |
| Insulation contractor |  |  |
| Drywall contractor |  |  |
| Painting contractor |  |  |
| Flooring contractor |  |  |
| Appliance contractor |  |  |
| Gary Clark |  |  |
| Maid service |  | 40 |
| Volunteer 1 |  |  |
| Volunteer 2 |  |  |
| Volunteer 3 |  |  |
| Volunteer 4 |  |  |
| Container |  | 2.5 |
| Waste Dump Fee | ton | 150 |
| Construction Fixed Cost |  |  |
| Project Budget |  |  |

## Schedule

| ID | WBS | Task | Type | Duration | Start | Finish | Predecessors | Total slack | Free slack | Constraint | Resources | Work | Cost |
| --- | --- | --- | --- | --- | --- | --- | --- | --- | --- | --- | --- | --- | --- |
| 1 | 1 | **General Conditions** |  | 56d? | 2016-05-02 | 2016-07-20 |  | -27.5d | 0d |  | Construction Fixed Cost [0.1%] | 606.4h | 183,280 |
| 2 | 1.1 | Finalize plans and develop estimate with owner, architect |  | 20d | 2016-05-02 | 2016-05-27 |  | -27.5d | 0d |  | General contractor [50%]; Architect [50%]; Owner [12%]; Mortgage lender [12%] | 198.4h |  |
| 3 | 1.2 | Sign contract and notice to proceed |  | 1d | 2016-05-31 | 2016-05-31 | 2 | -27.5d | 0d |  | General contractor; Architect; Owner; Mortgage lender | 32h |  |
| 4 | 1.3 | **Clear Old Home** |  | 25d? | 2016-06-15 | 2016-07-20 |  | -27.5d | 0d |  |  | 376h | 3,280 |
| 5 | 1.3.1 | Demolition of Old House |  | 2w? | 2016-06-15 | 2016-06-28 | 3FS+2w | -27.5d | 0d |  | Site excavation contractor | 80h |  |
| 6 | 1.3.2 | Place Containers |  | 2d | 2016-06-15 | 2016-07-11 | 5SS | -27.5d | 0d |  | Container [200%]; Gary Clark | 24h | 40 |
| 7 | 1.3.3 | Sort Debris |  | 5d | 2016-07-12 | 2016-07-18 | 6, 5FF+1d | -27.5d | 0d |  | Volunteer 1; Volunteer 2; Volunteer 3; Volunteer 4; Container [200%] | 240h | 200 |
| 8 | 1.3.4 | Haul Recycling |  | 1d | 2016-07-19 | 2016-07-19 | 7 | -27.5d | 0d | start no earlier than 2016-07-05 | Container; Gary Clark | 16h | 20 |
| 9 | 1.3.5 | Haul Waste |  | 2d | 2016-07-19 | 2016-07-20 | 7 | 136.5d |  |  | Container; Gary Clark; Waste Dump Fee [20 ton] | 16h | 3,020 |
| 10 | 1.4 | **Apply for Permits** |  | 0d | 2016-05-31 | 2016-05-31 |  | 6.5d |  |  |  |  |  |
| 11 | 1.4.1 | Secure foundation permit | milestone | 0d | 2016-05-31 | 2016-05-31 | 3 | 6.5d |  |  | General contractor |  |  |
| 12 | 1.4.2 | Secure framing permit | milestone | 0d | 2016-05-31 | 2016-05-31 | 3 | 6.5d |  |  | General contractor |  |  |
| 13 | 1.4.3 | Secure electrical permit | milestone | 0d | 2016-05-31 | 2016-05-31 | 3 | 6.5d |  |  | General contractor |  |  |
| 14 | 1.4.4 | Secure plumbing permit | milestone | 0d | 2016-05-31 | 2016-05-31 | 3 | 6.5d |  |  | General contractor |  |  |
| 15 | 1.4.5 | Secure HVAC permit | milestone | 0d | 2016-05-31 | 2016-05-31 | 3 | 6.5d |  |  | General contractor |  |  |
| 16 | 1.4.6 | Secure miscellaneous permits | milestone | 0d | 2016-05-31 | 2016-05-31 | 3 | 6.5d |  |  | General contractor |  |  |
| 17 | 2 | **Site Work** |  | 3d | 2016-07-20 | 2016-07-22 |  | -27.5d | 0d |  |  | 32h |  |
| 18 | 2.1 | Clear and grub lot |  | 1d | 2016-07-20 | 2016-07-20 | 11, 12, 13, 14, 16, 15, 8 | -27.5d | 0d |  | Site excavation contractor | 8h |  |
| 19 | 2.2 | Install temporary power service |  | 1d | 2016-07-21 | 2016-07-21 | 18 | -27.5d | 0d |  | Electric company | 8h |  |
| 20 | 2.3 | Install underground utilities |  | 1d | 2016-07-22 | 2016-07-22 | 19 | -27.5d | 0d |  | Electric contractor; Plumbing contractor | 16h |  |
| 21 | 3 | **Foundation** |  | 42d | 2016-07-25 | 2016-09-21 |  | -27.5d | 0d |  |  | 280h |  |
| 22 | 3.1 | Excavate for foundations |  | 3d | 2016-07-25 | 2016-07-27 | 20 | -27.5d | 0d |  | Site excavation contractor | 24h |  |
| 23 | 3.2 | Form basement walls |  | 13d | 2016-07-28 | 2016-08-15 | 22 | -27.5d | 0d |  | Concrete contractor | 104h |  |
| 24 | 3.3 | Place concrete for foundations & basement walls |  | 12d | 2016-08-16 | 2016-08-31 | 23 | -27.5d | 0d |  | Concrete contractor | 96h |  |
| 25 | 3.4 | Cure basement walls for 7 days |  | 7d | 2016-09-01 | 2016-09-12 | 24 | -27.5d | 0d |  |  |  |  |
| 26 | 3.5 | Strip basement wall forms |  | 2d | 2016-09-13 | 2016-09-14 | 25 | -27.5d | 0d |  | Concrete contractor | 16h |  |
| 27 | 3.6 | Waterproof/insulate basement walls |  | 2d | 2016-09-15 | 2016-09-16 | 26 | -27.5d | 0d |  | Concrete contractor | 16h |  |
| 28 | 3.7 | Perform foundation inspection |  | 1d | 2016-09-19 | 2016-09-19 | 27, 22 | -27.5d | 0d |  | Inspector | 8h |  |
| 29 | 3.8 | Backfill foundation |  | 2d | 2016-09-20 | 2016-09-21 | 28 | -27.5d | 0d |  | Site excavation contractor | 16h |  |

| ID | WBS | Task | Duration | Start | Finish | Predecessors | Total slack | Free slack | Constraint | Resources | Work |
| --- | --- | --- | --- | --- | --- | --- | --- | --- | --- | --- | --- |
| 30 | 4 | **Framing** | 22d | 2016-09-22 | 2016-10-21 |  | -27.5d | 0d |  |  | 176h |
| 31 | 4.1 | Install 1st floor joists | 2d | 2016-09-22 | 2016-09-23 | 29 | -27.5d | 0d |  | Framing contractor | 16h |
| 32 | 4.2 | Lay 1st floor decking | 2d | 2016-09-26 | 2016-09-27 | 31 | -27.5d | 0d |  | Framing contractor | 16h |
| 33 | 4.3 | Frame 1st floor walls | 4d | 2016-09-28 | 2016-10-03 | 32 | -27.5d | 0d |  | Framing contractor | 32h |
| 34 | 4.4 | Frame 1st floor corners | 1d | 2016-10-04 | 2016-10-04 | 33 | -27.5d | 0d |  | Framing contractor | 8h |
| 35 | 4.5 | Install 2nd floor joists | 2d | 2016-10-05 | 2016-10-06 | 34 | -27.5d | 0d |  | Framing contractor | 16h |
| 36 | 4.6 | Frame 2nd floor decking | 2d | 2016-10-07 | 2016-10-10 | 35 | -27.5d | 0d |  | Framing contractor | 16h |
| 37 | 4.7 | Frame 2nd floor walls | 3d | 2016-10-11 | 2016-10-13 | 36 | -27.5d | 0d |  | Framing contractor | 24h |
| 38 | 4.8 | Frame 2nd floor corners | 2d | 2016-10-14 | 2016-10-17 | 37 | -27.5d | 0d |  | Framing contractor | 16h |
| 39 | 4.9 | Complete roof framing | 3d | 2016-10-18 | 2016-10-20 | 38 | -27.5d | 0d |  | Framing contractor | 24h |
| 40 | 4.10 | Conduct framing inspection | 1d | 2016-10-21 | 2016-10-21 | 39 | -27.5d | 0d |  | Inspector | 8h |
| 41 | 5 | **Dry In** | 24d | 2016-10-21 | 2016-11-28 |  | -26.5d | 0d |  |  | 152h |
| 42 | 5.1 | Install 1st floor sheathing | 3d | 2016-10-24 | 2016-10-26 | 40 | -27.5d | 0d |  | Framing contractor | 24h |
| 43 | 5.2 | Install 2nd floor sheathing | 3d | 2016-10-31 | 2016-11-02 | 42 | -25.5d | 0d |  | Framing contractor | 24h |
| 44 | 5.3 | Install roof decking | 3d | 2016-10-21 | 2016-10-28 | 39 | -22.5d | 0d |  | Framing contractor | 24h |
| 45 | 5.4 | Install felt, flashing and shingles | 3d | 2016-11-10 | 2016-11-15 | 53 | -25.5d | 0d |  | Roofing contractor | 24h |
| 46 | 5.5 | Hang 1st floor exterior doors | 1d | 2016-11-15 | 2016-11-16 | 45 | -25.5d | 0d |  | Framing contractor | 8h |
| 47 | 5.6 | Install 1st floor windows | 3d | 2016-11-16 | 2016-11-21 | 46 | -25.5d | 0d |  | Framing contractor | 24h |
| 48 | 5.7 | Install 2nd floor windows | 3d | 2016-11-21 | 2016-11-28 | 47 | -25.5d | 0d |  | Framing contractor | 24h |
| 49 | 6 | **Exterior Finishes** | 19d | 2016-11-28 | 2016-12-23 |  | -20.5d | 0d |  |  | 152h |
| 50 | 6.1 | Complete exterior brick | 16d | 2016-11-28 | 2016-12-20 | 48 | -20.5d | 0d |  | Masonry contractor | 128h |
| 51 | 6.2 | Complete exterior siding | 3d | 2016-12-20 | 2016-12-23 | 50 | -20.5d | 0d |  | Framing contractor | 24h |
| 52 | 7 | **Utility Rough-B97Ins and Complete Concrete** | 20d | 2016-10-31 | 2016-11-30 |  | -22.5d | 0d |  |  | 232h |
| 53 | 7.1 | Rough-in plumbing | 5d | 2016-11-03 | 2016-11-10 | 44, 43 | -25.5d | 0d |  | Plumbing contractor | 40h |
| 54 | 7.2 | Conduct rough-in plumbing inspection | 1d | 2016-11-10 | 2016-11-11 | 53 | -5.5d | 0d |  | Inspector | 8h |
| 55 | 7.3 | Place concrete for basement floor | 11d | 2016-11-11 | 2016-11-30 | 54 | 13.5d |  |  | Concrete contractor | 88h |
| 56 | 7.4 | Rough-in electrical | 5d | 2016-11-03 | 2016-11-10 | 44, 43 | -19.5d | 0d |  | Electric contractor | 40h |
| 57 | 7.5 | Conduct rough-in electrical inspection | 1d | 2016-11-10 | 2016-11-11 | 56 | -19.5d | 0d | start no earlier than 2016-10-26 | Inspector | 8h |
| 58 | 7.6 | Rough-in HVAC | 3d | 2016-11-11 | 2016-11-16 | 57 | -19.5d | 0d |  | Heating and AC contractor | 24h |
| 59 | 7.7 | Conduct rough-in HVAC inspection | 1d | 2016-11-16 | 2016-11-17 | 58 | -1.5d | 0d |  | Inspector | 8h |
| 60 | 7.8 | Rough-in communication - phone, cable, computer, alarm | 2d | 2016-10-31 | 2016-11-01 | 44 | -9.5d | 0d |  | Electric contractor | 16h |

| ID | WBS | Task | Duration | Start | Finish | Predecessors | Total slack | Free slack | Resources | Work |
| --- | --- | --- | --- | --- | --- | --- | --- | --- | --- | --- |
| 61 | 8 | **Interior Finishes** | 30d | 2016-11-28 | 2017-01-11 |  | -25.5d | 0d |  | 408h |
| 62 | 8.1 | **Insulation** | 12d | 2016-11-28 | 2016-12-14 |  | -25.5d | 0d |  | 32h |
| 63 | 8.1.1 | Place wall insulation - 1st floor | 1d | 2016-11-28 | 2016-11-29 | 42, 48, 60, 58, 56, 43 | -25.5d | 0d | Insulation contractor | 8h |
| 64 | 8.1.2 | Place wall insulation - 2nd floor | 1d | 2016-11-29 | 2016-11-30 | 63 | 7.5d | 3d | Insulation contractor | 8h |
| 65 | 8.1.3 | Place ceiling insulation - 2nd floor | 1d | 2016-12-12 | 2016-12-13 | 71, 64 | 3.5d | 0d | Insulation contractor | 8h |
| 66 | 8.1.4 | Conduct insulation inspection | 1d | 2016-12-13 | 2016-12-14 | 65 | 3.5d |  | Inspector | 8h |
| 67 | 8.2 | **Drywall** | 10d | 2016-11-29 | 2016-12-13 |  | -25.5d | 0d |  | 80h |
| 68 | 8.2.1 | Install drywall - 1st floor walls | 2d | 2016-11-29 | 2016-12-01 | 63 | -25.5d | 0d | Drywall contractor | 16h |
| 69 | 8.2.2 | Install drywall - 1st floor overhead | 2d | 2016-12-01 | 2016-12-05 | 68 | -25.5d | 0d | Drywall contractor | 16h |
| 70 | 8.2.3 | Install drywall 2nd floor walls | 2d | 2016-12-06 | 2016-12-08 | 69, 64 | 3.5d | 0d | Drywall contractor | 16h |
| 71 | 8.2.4 | Install drywall 2nd floor overhead | 2d | 2016-12-08 | 2016-12-12 | 70 | 3.5d | 0d | Drywall contractor | 16h |
| 72 | 8.2.5 | Tape and float 1st floor drywall | 1d | 2016-12-05 | 2016-12-06 | 69 | -25.5d | 0d | Drywall contractor | 8h |
| 73 | 8.2.6 | Tape and float 2nd floor drywall | 1d | 2016-12-12 | 2016-12-13 | 71, 72 | 37.5d |  | Drywall contractor | 8h |
| 74 | 8.3 | **Paint and Wallpaper** | 17d | 2016-12-06 | 2016-12-30 |  | -25.5d | 0d |  | 72h |
| 75 | 8.3.1 | Texture all except entry and kitchen - 1st floor | 1d | 2016-12-06 | 2016-12-07 | 72 | -25.5d | 0d | Painting contractor | 8h |
| 76 | 8.3.2 | Paint all except entry and kitchen - 1st floor | 1d | 2016-12-07 | 2016-12-08 | 75 | -25.5d | 0d | Painting contractor | 8h |
| 77 | 8.3.3 | Hang wallpaper entry and kitchen - 1st floor | 1d | 2016-12-08 | 2016-12-09 | 76 | -25.5d | 0d | Painting contractor | 8h |
| 78 | 8.3.4 | Texture all - 2nd floor | 1d | 2016-12-09 | 2016-12-12 | 75 | 37.5d | 0d | Painting contractor | 8h |
| 79 | 8.3.5 | Paint all - 2nd floor | 1d | 2016-12-12 | 2016-12-13 | 78 | 37.5d | 40d | Painting contractor | 8h |
| 80 | 8.3.6 | Paint exterior siding & trim work | 4d | 2016-12-23 | 2016-12-30 | 51 | -20.5d | 0d | Painting contractor | 32h |
| 81 | 8.4 | **Cabinets** | 6d | 2016-12-09 | 2016-12-19 |  | -25.5d | 0d |  | 48h |
| 82 | 8.4.1 | Install 1st floor - kitchen cabinets | 2d | 2016-12-09 | 2016-12-13 | 77 | -25.5d | 0d | Finish carpentry contractor | 16h |
| 83 | 8.4.2 | Install 1st floor - master bath and guest cabinets | 1d | 2016-12-13 | 2016-12-14 | 82 | -25.5d | 0d | Finish carpentry contractor | 8h |
| 84 | 8.4.3 | Install 2nd floor - hall bath and private bath cabinets | 1d | 2016-12-14 | 2016-12-15 | 83 | -24.5d | 0d | Finish carpentry contractor | 8h |
| 85 | 8.4.4 | Install chair rails, crown moldings, trim | 2d | 2016-12-15 | 2016-12-19 | 84 | 0.5d |  | Finish carpentry contractor | 16h |

| ID | WBS | Task | Duration | Start | Finish | Predecessors | Total slack | Free slack | Resources | Work |
| --- | --- | --- | --- | --- | --- | --- | --- | --- | --- | --- |
| 86 | 8.5 | **Finish Plumbing** | 6d | 2016-12-13 | 2016-12-21 |  | -25.5d | 0d |  | 48h |
| 87 | 8.5.1 | Complete 1st floor - kitchen plumbing | 1d | 2016-12-13 | 2016-12-14 | 82, 54 | -25.5d | 0d | Plumbing contractor | 8h |
| 88 | 8.5.2 | Complete 1st floor - master bath and guest plumbing | 2d | 2016-12-14 | 2016-12-16 | 87, 83 | -25.5d | 0d | Plumbing contractor | 16h |
| 89 | 8.5.3 | Complete 2nd floor - hall bath and private bath plumbing | 2d | 2016-12-16 | 2016-12-20 | 88, 84 | -25.5d | 0d | Plumbing contractor | 16h |
| 90 | 8.5.4 | Conduct finish plumbing inspection | 1d | 2016-12-20 | 2016-12-21 | 89 | -25.5d | 0d | Inspector | 8h |
| 91 | 8.6 | **Finish Electrical** | 5d | 2016-12-20 | 2016-12-28 |  | -24.5d | 0d |  | 40h |
| 92 | 8.6.1 | Complete 1st floor circuits to service panel | 1d | 2016-12-20 | 2016-12-21 | 89, 57 | -24.5d | 0d | Electric contractor | 8h |
| 93 | 8.6.2 | Complete 2nd floor circuits to service panel | 1d | 2016-12-23 | 2016-12-27 | 92 | -24.5d | 0d | Electric contractor | 8h |
| 94 | 8.6.3 | Conduct finish electrical inspection | 1d | 2016-12-27 | 2016-12-28 | 93 | -24.5d | 0d | Inspector | 8h |
| 95 | 8.6.4 | Complete communications wiring - phone, cable, computer, alarm | 2d | 2016-12-21 | 2016-12-23 | 90 | -25.5d | 0d | Electric contractor | 16h |
| 96 | 8.7 | **Finish HVAC** | 3d | 2016-12-23 | 2016-12-29 |  | -25.5d | 0d |  | 24h |
| 97 | 8.7.1 | Complete 1st floor - zone 1 HVAC | 1d | 2016-12-23 | 2016-12-27 | 95, 59 | -25.5d | 0d | Heating and AC contractor | 8h |
| 98 | 8.7.2 | Complete 2nd floor - zone 2 HVAC | 1d | 2016-12-27 | 2016-12-28 | 97 | -25.5d | 0d | Heating and AC contractor | 8h |
| 99 | 8.7.3 | Conduct HVAC inspection | 1d | 2016-12-28 | 2016-12-29 | 98 | -25.5d | 0d | Inspector | 8h |
| 100 | 8.8 | **Carpet, Tile and Appliances** | 8d | 2016-12-29 | 2017-01-11 |  | -25.5d | 0d |  | 64h |
| 101 | 8.8.1 | Tile entry, kitchen and baths | 3d | 2016-12-29 | 2017-01-04 | 94, 99 | -25.5d | 0d | Flooring contractor | 24h |
| 102 | 8.8.2 | Carpet 1st floor | 2d | 2017-01-04 | 2017-01-06 | 101 | -25.5d | 0d | Flooring contractor | 16h |
| 103 | 8.8.3 | Carpet 2nd floor | 2d | 2017-01-06 | 2017-01-10 | 102 | -25.5d | 0d | Flooring contractor | 16h |
| 104 | 8.8.4 | Install appliances | 1d | 2017-01-10 | 2017-01-11 | 103 | -25.5d | 0d | Appliance contractor | 8h |
| 105 | 9 | **Landscaping and Grounds Work** | 20.5d | 2016-12-30 | 2017-01-30 |  | -20.5d | 0d |  | 104h |
| 106 | 9.1 | Pour concrete driveway and sidewalks | 2d | 2016-12-30 | 2017-01-04 | 80 | -20.5d | 0d | Concrete contractor | 16h |
| 107 | 9.2 | Install backyard fence | 2d | 2017-01-11 | 2017-01-13 | 104, 106 | -25.5d | 0d | Fencing contractor | 16h |
| 108 | 9.3 | Order Plants and Trees | 1d | 2017-01-16 | 2017-01-16 | 107 | -26d | 0d | Gary Clark | 8h |
| 109 | 9.4 | Build Compost Bin | 1d | 2017-01-17 | 2017-01-17 | 108 | -26d | 0d | Gary Clark | 8h |
| 110 | 9.5 | Build Flower Beds and Edges | 2d | 2017-01-18 | 2017-01-19 | 109 | -25d | 0d | Gary Clark | 16h |
| 111 | 9.6 | Weed and Trim Existing Yard | 2d | 2017-01-23 | 2017-01-24 | 110 | -26d | 0d | Gary Clark | 16h |
| 112 | 9.7 | Plant New Plants and Trees | 2d | 2017-01-25 | 2017-01-26 | 111 | -25d | 0d | Gary Clark | 16h |
| 113 | 9.8 | Re-Seed Bare Lawn Areas | 1d | 2017-01-30 | 2017-01-30 | 112 | 5d |  | Gary Clark | 8h |

Notes:
- 105: Additional tasks provided by Gary Clark.

| ID | WBS | Task | Type | Duration | Start | Finish | Predecessors | Total slack | Free slack | Deadline | Resources | Work | Cost |
| --- | --- | --- | --- | --- | --- | --- | --- | --- | --- | --- | --- | --- | --- |
| 114 | 10 | **Final Acceptance** |  | 26.5d | 2016-12-29 | 2017-02-06 |  | -25d | 0d |  |  | 64h | 400 |
| 115 | 10.1 | Complete final inspection for certificate of occupancy |  | 1d | 2016-12-29 | 2016-12-30 | 99, 94, 90, 66, 85, 55 | -6.5d | 0d |  | Inspector | 8h |  |
| 116 | 10.2 | Cleanup for occupancy |  | 1d | 2017-01-27 | 2017-01-27 | 104, 115, 112 | -25d | 0d |  | Maid service | 8h | 400 |
| 117 | 10.3 | Perform final walk-through inspection |  | 1d | 2017-01-30 | 2017-01-30 | 116 | -25d | 0d |  | Owner | 8h |  |
| 118 | 10.4 | Complete punch list items |  | 5d | 2017-01-31 | 2017-02-06 | 117 | -25d | 0d |  | General contractor | 40h |  |
| 119 | 10.5 | Ready for Move-In | milestone | 0d | 2017-02-06 | 2017-02-06 | 118 | -25d | 0d | 2016-12-31 |  |  |  |
