# Woods Family 3BR Home

Schedule from MS Project, 2016-05-02 to 2017-01-20, costs in $.
Residential Construction
Building with Heart
Clear debris. Two girls. Greene City Interiors for finishing.

## Calendars

- BWH Standard Calendar: Mon-Fri 08:00-12:00, 13:00-17:00; Sat-Sun off. Exceptions (off unless hours are given): 2016-05-30 to 2025-05-26 (Memorial Day, recurring), 2016-07-04 (Independence Day), 2016-09-05 (Labor Day), 2016-11-08 08:00-12:00 (Election Day), 2016-11-24 (Thanksgiving Day), 2016-11-25 (Black Friday), 2016-12-26 (Christmas Day (observed)), 2017-01-02 (New Year's Day (observed)).

## Resources

| Resource | Unit | Rate |
| --- | --- | --- |
| Concrete contractor |  |  |
| Finish carpentry contractor |  |  |
| Fencing contractor |  |  |
| Masonry contractor |  |  |
| General contractor |  |  |
| Architect |  |  |
| Owner |  |  |
| Mortgage lender |  |  |
| Inspector |  |  |
| Electric company |  |  |
| Site excavation contractor |  |  |
| Electric contractor |  |  |
| Plumbing contractor |  |  |
| Framing contractor |  |  |
| Roofing contractor |  |  |
| Heating and AC contractor |  |  |
| Insulation contractor |  |  |
| Drywall contractor |  |  |
| Painting contractor |  |  |
| Flooring contractor |  |  |
| Appliance contractor |  |  |
| Gary Clark |  |  |
| Maid service |  | 40 |
| Volunteer 1 |  |  |
| Volunteer 2 |  |  |
| Volunteer 3 |  |  |
| Volunteer 4 |  |  |
| Container |  | 2.5 |
| Waste Dump Fee | ton | 150 |
| Construction Fixed Cost |  |  |
| Project Budget |  |  |

## Schedule

| ID | WBS | Task | Type | Duration | Start | Finish | Predecessors | Total slack | Free slack | Constraint | Resources | Work | Cost |
| --- | --- | --- | --- | --- | --- | --- | --- | --- | --- | --- | --- | --- | --- |
| 1 | 1 | **General Conditions** |  | 45d? | 2016-05-02 | 2016-07-05 |  | -11.5d | 0d |  | Construction Fixed Cost [0.1%] | 606.4h | 183,280 |
| 2 | 1.1 | Finalize plans and develop estimate with owner, architect |  | 20d | 2016-05-02 | 2016-05-27 |  | -11.5d | 0d |  | General contractor [50%]; Architect [50%]; Owner [12%]; Mortgage lender [12%] | 198.4h |  |
| 3 | 1.2 | Sign contract and notice to proceed |  | 1d | 2016-05-31 | 2016-05-31 | 2 | -11.5d | 0d |  | General contractor; Architect; Owner; Mortgage lender | 32h |  |
| 4 | 1.3 | **Clear Old Home** |  | 14d? | 2016-06-15 | 2016-07-05 |  | -11.5d | 0d |  |  | 376h | 3,280 |
| 5 | 1.3.1 | Demolition of Old House |  | 2w? | 2016-06-15 | 2016-06-28 | 3FS+2w | -11.5d | 0d |  | Site excavation contractor | 80h |  |
| 6 | 1.3.2 | Place Containers |  | 1d | 2016-06-15 | 2016-06-15 | 5SS | -6.5d | 0d |  | Container [200%]; Gary Clark | 24h | 40 |
| 7 | 1.3.3 | Sort Debris |  | 5d | 2016-06-23 | 2016-06-29 | 6, 5FF+1d | -11.5d | 0d |  | Volunteer 1; Volunteer 2; Volunteer 3; Volunteer 4; Container [200%] | 240h | 200 |
| 8 | 1.3.4 | Haul Recycling |  | 1d | 2016-07-05 | 2016-07-05 | 7 | -13.5d | 0d | start no earlier than 2016-07-05 | Container; Gary Clark | 16h | 20 |
| 9 | 1.3.5 | Haul Waste |  | 1d | 2016-06-30 | 2016-06-30 | 7 | 138.5d |  |  | Container; Gary Clark; Waste Dump Fee [20 ton] | 16h | 3,020 |
| 10 | 1.4 | **Apply for Permits** |  | 0d | 2016-05-31 | 2016-05-31 |  | 10.5d |  |  |  |  |  |
| 11 | 1.4.1 | Secure foundation permit | milestone | 0d | 2016-05-31 | 2016-05-31 | 3 | 10.5d |  |  | General contractor |  |  |
| 12 | 1.4.2 | Secure framing permit | milestone | 0d | 2016-05-31 | 2016-05-31 | 3 | 10.5d |  |  | General contractor |  |  |
| 13 | 1.4.3 | Secure electrical permit | milestone | 0d | 2016-05-31 | 2016-05-31 | 3 | 10.5d |  |  | General contractor |  |  |
| 14 | 1.4.4 | Secure plumbing permit | milestone | 0d | 2016-05-31 | 2016-05-31 | 3 | 10.5d |  |  | General contractor |  |  |
| 15 | 1.4.5 | Secure HVAC permit | milestone | 0d | 2016-05-31 | 2016-05-31 | 3 | 10.5d |  |  | General contractor |  |  |
| 16 | 1.4.6 | Secure miscellaneous permits | milestone | 0d | 2016-05-31 | 2016-05-31 | 3 | 10.5d |  |  | General contractor |  |  |
| 17 | 2 | **Site Work** |  | 3d | 2016-07-06 | 2016-07-08 |  | -13.5d | 0d |  |  | 32h |  |
| 18 | 2.1 | Clear and grub lot |  | 1d | 2016-07-06 | 2016-07-06 | 11, 12, 13, 14, 16, 15, 8 | -13.5d | 0d |  | Site excavation contractor | 8h |  |
| 19 | 2.2 | Install temporary power service |  | 1d | 2016-07-07 | 2016-07-07 | 18 | -13.5d | 0d |  | Electric company | 8h |  |
| 20 | 2.3 | Install underground utilities |  | 1d | 2016-07-08 | 2016-07-08 | 19 | -13.5d | 0d |  | Electric contractor; Plumbing contractor | 16h |  |
| 21 | 3 | **Foundation** |  | 42d | 2016-07-11 | 2016-09-07 |  | -13.5d | 0d |  |  | 280h |  |
| 22 | 3.1 | Excavate for foundations |  | 3d | 2016-07-11 | 2016-07-13 | 20 | -13.5d | 0d |  | Site excavation contractor | 24h |  |
| 23 | 3.2 | Form basement walls |  | 13d | 2016-07-14 | 2016-08-01 | 22 | -13.5d | 0d |  | Concrete contractor | 104h |  |
| 24 | 3.3 | Place concrete for foundations & basement walls |  | 12d | 2016-08-02 | 2016-08-17 | 23 | -13.5d | 0d |  | Concrete contractor | 96h |  |
| 25 | 3.4 | Cure basement walls for 7 days |  | 7d | 2016-08-18 | 2016-08-26 | 24 | -13.5d | 0d |  |  |  |  |
| 26 | 3.5 | Strip basement wall forms |  | 2d | 2016-08-29 | 2016-08-30 | 25 | -13.5d | 0d |  | Concrete contractor | 16h |  |
| 27 | 3.6 | Waterproof/insulate basement walls |  | 2d | 2016-08-31 | 2016-09-01 | 26 | -13.5d | 0d |  | Concrete contractor | 16h |  |
| 28 | 3.7 | Perform foundation inspection |  | 1d | 2016-09-02 | 2016-09-02 | 27, 22 | -13.5d | 0d |  | Inspector | 8h |  |
| 29 | 3.8 | Backfill foundation |  | 2d | 2016-09-06 | 2016-09-07 | 28 | -13.5d | 0d |  | Site excavation contractor | 16h |  |

| ID | WBS | Task | Duration | Start | Finish | Predecessors | Total slack | Free slack | Resources | Work |
| --- | --- | --- | --- | --- | --- | --- | --- | --- | --- | --- |
| 30 | 4 | **Framing** | 22d | 2016-09-08 | 2016-10-07 |  | -13.5d | 0d |  | 176h |
| 31 | 4.1 | Install 1st floor joists | 2d | 2016-09-08 | 2016-09-09 | 29 | -13.5d | 0d | Framing contractor | 16h |
| 32 | 4.2 | Lay 1st floor decking | 2d | 2016-09-12 | 2016-09-13 | 31 | -13.5d | 0d | Framing contractor | 16h |
| 33 | 4.3 | Frame 1st floor walls | 4d | 2016-09-14 | 2016-09-19 | 32 | -13.5d | 0d | Framing contractor | 32h |
| 34 | 4.4 | Frame 1st floor corners | 1d | 2016-09-20 | 2016-09-20 | 33 | -13.5d | 0d | Framing contractor | 8h |
| 35 | 4.5 | Install 2nd floor joists | 2d | 2016-09-21 | 2016-09-22 | 34 | -13.5d | 0d | Framing contractor | 16h |
| 36 | 4.6 | Frame 2nd floor decking | 2d | 2016-09-23 | 2016-09-26 | 35 | -13.5d | 0d | Framing contractor | 16h |
| 37 | 4.7 | Frame 2nd floor walls | 3d | 2016-09-27 | 2016-09-29 | 36 | -13.5d | 0d | Framing contractor | 24h |
| 38 | 4.8 | Frame 2nd floor corners | 2d | 2016-09-30 | 2016-10-03 | 37 | -13.5d | 0d | Framing contractor | 16h |
| 39 | 4.9 | Complete roof framing | 3d | 2016-10-04 | 2016-10-06 | 38 | -13.5d | 0d | Framing contractor | 24h |
| 40 | 4.10 | Conduct framing inspection | 1d | 2016-10-07 | 2016-10-07 | 39 | -13.5d | 0d | Inspector | 8h |
| 41 | 5 | **Dry In** | 22d | 2016-10-07 | 2016-11-07 |  | -13.5d | 0d |  | 152h |
| 42 | 5.1 | Install 1st floor sheathing | 3d | 2016-10-10 | 2016-10-12 | 40 | -13.5d | 0d | Framing contractor | 24h |
| 43 | 5.2 | Install 2nd floor sheathing | 3d | 2016-10-13 | 2016-10-17 | 42 | -13.5d | 0d | Framing contractor | 24h |
| 44 | 5.3 | Install roof decking | 3d | 2016-10-07 | 2016-10-11 | 39 | -9.5d | 0d | Framing contractor | 24h |
| 45 | 5.4 | Install felt, flashing and shingles | 3d | 2016-10-25 | 2016-10-27 | 53 | -13.5d | 0d | Roofing contractor | 24h |
| 46 | 5.5 | Hang 1st floor exterior doors | 1d | 2016-10-28 | 2016-10-28 | 45 | -13.5d | 0d | Framing contractor | 8h |
| 47 | 5.6 | Install 1st floor windows | 3d | 2016-10-31 | 2016-11-02 | 46 | -13.5d | 0d | Framing contractor | 24h |
| 48 | 5.7 | Install 2nd floor windows | 3d | 2016-11-03 | 2016-11-07 | 47 | -13.5d | 0d | Framing contractor | 24h |
| 49 | 6 | **Exterior Finishes** | 19d | 2016-11-08 | 2016-12-07 |  | -8.5d | 0d |  | 152h |
| 50 | 6.1 | Complete exterior brick | 16d | 2016-11-08 | 2016-12-02 | 48 | -8.5d | 0d | Masonry contractor | 128h |
| 51 | 6.2 | Complete exterior siding | 3d | 2016-12-02 | 2016-12-07 | 50 | -8.5d | 0d | Framing contractor | 24h |
| 52 | 7 | **Utility Rough-B97Ins and Complete Concrete** | 21d | 2016-10-12 | 2016-11-10 |  | -9.5d | 0d |  | 232h |
| 53 | 7.1 | Rough-in plumbing | 5d | 2016-10-18 | 2016-10-24 | 44, 43 | -13.5d | 0d | Plumbing contractor | 40h |
| 54 | 7.2 | Conduct rough-in plumbing inspection | 1d | 2016-10-25 | 2016-10-25 | 53 | 6.5d | 0d | Inspector | 8h |
| 55 | 7.3 | Place concrete for basement floor | 11d | 2016-10-26 | 2016-11-10 | 54 | 25.5d | 20d | Concrete contractor | 88h |
| 56 | 7.4 | Rough-in electrical | 5d | 2016-10-18 | 2016-10-24 | 44, 43 | -7.5d | 0d | Electric contractor | 40h |
| 57 | 7.5 | Conduct rough-in electrical inspection | 1d | 2016-10-25 | 2016-10-25 | 56 | -7.5d | 0d | Inspector | 8h |
| 58 | 7.6 | Rough-in HVAC | 3d | 2016-10-26 | 2016-10-28 | 57 | -7.5d | 0d | Heating and AC contractor | 24h |
| 59 | 7.7 | Conduct rough-in HVAC inspection | 1d | 2016-10-31 | 2016-10-31 | 58 | 10.5d |  | Inspector | 8h |
| 60 | 7.8 | Rough-in communication - phone, cable, computer, alarm | 2d | 2016-10-12 | 2016-10-13 | 44 | 3.5d |  | Electric contractor | 16h |

| ID | WBS | Task | Duration | Start | Finish | Predecessors | Total slack | Free slack | Resources | Work |
| --- | --- | --- | --- | --- | --- | --- | --- | --- | --- | --- |
| 61 | 8 | **Interior Finishes** | 30d | 2016-11-08 | 2016-12-22 |  | -13.5d | 0d |  | 408h |
| 62 | 8.1 | **Insulation** | 11d | 2016-11-08 | 2016-11-23 |  | -13.5d | 0d |  | 32h |
| 63 | 8.1.1 | Place wall insulation - 1st floor | 1d | 2016-11-08 | 2016-11-09 | 42, 48, 60, 58, 56, 43 | -13.5d | 0d | Insulation contractor | 8h |
| 64 | 8.1.2 | Place wall insulation - 2nd floor | 1d | 2016-11-09 | 2016-11-10 | 63 | 19.5d | 3d | Insulation contractor | 8h |
| 65 | 8.1.3 | Place ceiling insulation - 2nd floor | 1d | 2016-11-21 | 2016-11-22 | 71, 64 | 16.5d | 0d | Insulation contractor | 8h |
| 66 | 8.1.4 | Conduct insulation inspection | 1d | 2016-11-22 | 2016-11-23 | 65 | 16.5d | 11d | Inspector | 8h |
| 67 | 8.2 | **Drywall** | 9d | 2016-11-09 | 2016-11-22 |  | -13.5d | 0d |  | 80h |
| 68 | 8.2.1 | Install drywall - 1st floor walls | 2d | 2016-11-09 | 2016-11-11 | 63 | -13.5d | 0d | Drywall contractor | 16h |
| 69 | 8.2.2 | Install drywall - 1st floor overhead | 2d | 2016-11-11 | 2016-11-15 | 68 | -13.5d | 0d | Drywall contractor | 16h |
| 70 | 8.2.3 | Install drywall 2nd floor walls | 2d | 2016-11-15 | 2016-11-17 | 69, 64 | 16.5d | 0d | Drywall contractor | 16h |
| 71 | 8.2.4 | Install drywall 2nd floor overhead | 2d | 2016-11-17 | 2016-11-21 | 70 | 16.5d | 0d | Drywall contractor | 16h |
| 72 | 8.2.5 | Tape and float 1st floor drywall | 1d | 2016-11-15 | 2016-11-16 | 69 | -13.5d | 0d | Drywall contractor | 8h |
| 73 | 8.2.6 | Tape and float 2nd floor drywall | 1d | 2016-11-21 | 2016-11-22 | 71, 72 | 39d |  | Drywall contractor | 8h |
| 74 | 8.3 | **Paint and Wallpaper** | 17d | 2016-11-16 | 2016-12-13 |  | -13.5d | 0d |  | 72h |
| 75 | 8.3.1 | Texture all except entry and kitchen - 1st floor | 1d | 2016-11-16 | 2016-11-17 | 72 | -13.5d | 0d | Painting contractor | 8h |
| 76 | 8.3.2 | Paint all except entry and kitchen - 1st floor | 1d | 2016-11-17 | 2016-11-18 | 75 | -13.5d | 0d | Painting contractor | 8h |
| 77 | 8.3.3 | Hang wallpaper entry and kitchen - 1st floor | 1d | 2016-11-18 | 2016-11-21 | 76 | -13.5d | 0d | Painting contractor | 8h |
| 78 | 8.3.4 | Texture all - 2nd floor | 1d | 2016-11-17 | 2016-11-18 | 75 | 40d | 0d | Painting contractor | 8h |
| 79 | 8.3.5 | Paint all - 2nd floor | 1d | 2016-11-18 | 2016-11-21 | 78 | 40d |  | Painting contractor | 8h |
| 80 | 8.3.6 | Paint exterior siding & trim work | 4d | 2016-12-07 | 2016-12-13 | 51 | -8.5d | 0d | Painting contractor | 32h |
| 81 | 8.4 | **Cabinets** | 6d | 2016-11-21 | 2016-12-01 |  | -13.5d | 0d |  | 48h |
| 82 | 8.4.1 | Install 1st floor - kitchen cabinets | 2d | 2016-11-21 | 2016-11-23 | 77 | -13.5d | 0d | Finish carpentry contractor | 16h |
| 83 | 8.4.2 | Install 1st floor - master bath and guest cabinets | 1d | 2016-11-23 | 2016-11-28 | 82 | -13.5d | 0d | Finish carpentry contractor | 8h |
| 84 | 8.4.3 | Install 2nd floor - hall bath and private bath cabinets | 1d | 2016-11-28 | 2016-11-29 | 83 | -12.5d | 0d | Finish carpentry contractor | 8h |
| 85 | 8.4.4 | Install chair rails, crown moldings, trim | 2d | 2016-11-29 | 2016-12-01 | 84 | 12.5d | 7d | Finish carpentry contractor | 16h |

| ID | WBS | Task | Duration | Start | Finish | Predecessors | Total slack | Free slack | Resources | Work |
| --- | --- | --- | --- | --- | --- | --- | --- | --- | --- | --- |
| 86 | 8.5 | **Finish Plumbing** | 6d | 2016-11-23 | 2016-12-05 |  | -13.5d | 0d |  | 48h |
| 87 | 8.5.1 | Complete 1st floor - kitchen plumbing | 1d | 2016-11-23 | 2016-11-28 | 82, 54 | -13.5d | 0d | Plumbing contractor | 8h |
| 88 | 8.5.2 | Complete 1st floor - master bath and guest plumbing | 2d | 2016-11-28 | 2016-11-30 | 87, 83 | -13.5d | 0d | Plumbing contractor | 16h |
| 89 | 8.5.3 | Complete 2nd floor - hall bath and private bath plumbing | 2d | 2016-11-30 | 2016-12-02 | 88, 84 | -13.5d | 0d | Plumbing contractor | 16h |
| 90 | 8.5.4 | Conduct finish plumbing inspection | 1d | 2016-12-02 | 2016-12-05 | 89 | -13.5d | 0d | Inspector | 8h |
| 91 | 8.6 | **Finish Electrical** | 3d | 2016-12-02 | 2016-12-07 |  | -12.5d | 0d |  | 40h |
| 92 | 8.6.1 | Complete 1st floor circuits to service panel | 1d | 2016-12-02 | 2016-12-05 | 89, 57 | -10.5d | 0d | Electric contractor | 8h |
| 93 | 8.6.2 | Complete 2nd floor circuits to service panel | 1d | 2016-12-05 | 2016-12-06 | 92 | -10.5d | 0d | Electric contractor | 8h |
| 94 | 8.6.3 | Conduct finish electrical inspection | 1d | 2016-12-06 | 2016-12-07 | 93 | -10.5d | 0d | Inspector | 8h |
| 95 | 8.6.4 | Complete communications wiring - phone, cable, computer, alarm | 2d | 2016-12-05 | 2016-12-07 | 90 | -13.5d | 0d | Electric contractor | 16h |
| 96 | 8.7 | **Finish HVAC** | 3d | 2016-12-07 | 2016-12-12 |  | -13.5d | 0d |  | 24h |
| 97 | 8.7.1 | Complete 1st floor - zone 1 HVAC | 1d | 2016-12-07 | 2016-12-08 | 95, 59 | -13.5d | 0d | Heating and AC contractor | 8h |
| 98 | 8.7.2 | Complete 2nd floor - zone 2 HVAC | 1d | 2016-12-08 | 2016-12-09 | 97 | -13.5d | 0d | Heating and AC contractor | 8h |
| 99 | 8.7.3 | Conduct HVAC inspection | 1d | 2016-12-09 | 2016-12-12 | 98 | -13.5d | 0d | Inspector | 8h |
| 100 | 8.8 | **Carpet, Tile and Appliances** | 8d | 2016-12-12 | 2016-12-22 |  | -13.5d | 0d |  | 64h |
| 101 | 8.8.1 | Tile entry, kitchen and baths | 3d | 2016-12-12 | 2016-12-15 | 94, 99 | -13.5d | 0d | Flooring contractor | 24h |
| 102 | 8.8.2 | Carpet 1st floor | 2d | 2016-12-15 | 2016-12-19 | 101 | -13.5d | 0d | Flooring contractor | 16h |
| 103 | 8.8.3 | Carpet 2nd floor | 2d | 2016-12-19 | 2016-12-21 | 102 | -13.5d | 0d | Flooring contractor | 16h |
| 104 | 8.8.4 | Install appliances | 1d | 2016-12-21 | 2016-12-22 | 103 | -13.5d | 0d | Appliance contractor | 8h |
| 105 | 9 | **Landscaping and Grounds Work** | 20d | 2016-12-13 | 2017-01-12 |  | -8.5d | 0d |  | 104h |
| 106 | 9.1 | Pour concrete driveway and sidewalks | 2d | 2016-12-13 | 2016-12-15 | 80 | -8.5d | 0d | Concrete contractor | 16h |
| 107 | 9.2 | Install backyard fence | 2d | 2016-12-22 | 2016-12-27 | 104, 106 | -13.5d | 0d | Fencing contractor | 16h |
| 108 | 9.3 | Order Plants and Trees | 1d | 2016-12-27 | 2016-12-28 | 107 | -13.5d | 0d | Gary Clark | 8h |
| 109 | 9.4 | Build Compost Bin | 1d | 2016-12-28 | 2016-12-29 | 108 | -13.5d | 0d | Gary Clark | 8h |
| 110 | 9.5 | Build Flower Beds and Edges | 2d | 2016-12-29 | 2017-01-04 | 109 | -13.5d | 0d | Gary Clark | 16h |
| 111 | 9.6 | Weed and Trim Existing Yard | 2d | 2017-01-04 | 2017-01-09 | 110 | -14.5d | 0d | Gary Clark | 16h |
| 112 | 9.7 | Plant New Plants and Trees | 2d | 2017-01-09 | 2017-01-11 | 111 | -13.5d | 0d | Gary Clark | 16h |
| 113 | 9.8 | Re-Seed Bare Lawn Areas | 1d | 2017-01-11 | 2017-01-12 | 112 | 5.5d |  | Gary Clark | 8h |

Notes:
- 105: Additional tasks provided by Gary Clark.

| ID | WBS | Task | Type | Duration | Start | Finish | Predecessors | Total slack | Free slack | Deadline | Resources | Work | Cost |
| --- | --- | --- | --- | --- | --- | --- | --- | --- | --- | --- | --- | --- | --- |
| 114 | 10 | **Final Acceptance** |  | 27d | 2016-12-12 | 2017-01-20 |  | -13.5d | 0d |  |  | 64h | 400 |
| 115 | 10.1 | Complete final inspection for certificate of occupancy |  | 1d | 2016-12-12 | 2016-12-13 | 99, 94, 90, 66, 85, 55 | 5.5d |  |  | Inspector | 8h |  |
| 116 | 10.2 | Cleanup for occupancy |  | 1d | 2017-01-11 | 2017-01-12 | 104, 115, 112 | -13.5d | 0d |  | Maid service | 8h | 400 |
| 117 | 10.3 | Perform final walk-through inspection |  | 1d | 2017-01-12 | 2017-01-13 | 116 | -13.5d | 0d |  | Owner | 8h |  |
| 118 | 10.4 | Complete punch list items |  | 5d | 2017-01-13 | 2017-01-20 | 117 | -13.5d | 0d |  | General contractor | 40h |  |
| 119 | 10.5 | Ready for Move-In | milestone | 0d | 2017-01-20 | 2017-01-20 | 118 | -13.5d | 0d | 2016-12-31 |  |  |  |
