# Woods Family 3BR Home

Schedule from MS Project, 2016-05-02 to 2016-11-22.
Residential Construction
Building with Heart
Clear debris. Two girls. Greene City Interiors for finishing.

## Calendars

- BWH Standard Calendar: Mon-Fri 08:00-12:00, 13:00-17:00; Sat-Sun off. Exceptions (off unless hours are given): 2016-05-30 to 2025-05-26 (Memorial Day, recurring), 2016-07-04 (Independence Day), 2016-09-05 (Labor Day), 2016-11-08 08:00-12:00 (Election Day).

## Resources

| Resource |
| --- |
| Concrete contractor |
| Finish carpentry contractor |
| Fencing contractor |
| Masonry contractor |
| General contractor |
| Architect |
| Owner |
| Mortgage lender |
| Inspector |
| Electric company |
| Site excavation contractor |
| Electric contractor |
| Plumbing contractor |
| Framing contractor |
| Roofing contractor |
| Heating and AC contractor |
| Insulation contractor |
| Drywall contractor |
| Painting contractor |
| Flooring contractor |
| Appliance contractor |
| Landscape contractor |
| Maid service |

## Schedule

| ID | WBS | Task | Type | Duration | Start | Finish | Predecessors | Total slack | Free slack | Constraint | Resources | Work |
| --- | --- | --- | --- | --- | --- | --- | --- | --- | --- | --- | --- | --- |
| 1 | 1 | **General Conditions** |  | 45d? | 2016-05-02 | 2016-07-05 |  | 0d |  |  |  | 230.4h |
| 2 | 1.1 | Finalize plans and develop estimate with owner, architect |  | 20d | 2016-05-02 | 2016-05-27 |  | 0d |  |  | General contractor [50%]; Architect [50%]; Owner [12%]; Mortgage lender [12%] | 198.4h |
| 3 | 1.2 | Sign contract and notice to proceed |  | 1d | 2016-05-30 | 2016-05-30 | 2 | 0d |  |  | General contractor; Architect; Owner; Mortgage lender | 32h |
| 4 | 1.3 | **Clear Old Home** |  | 15d? | 2016-06-14 | 2016-07-05 |  | 98.5d |  |  |  |  |
| 5 | 1.3.1 | Demolition of Old House |  | 2w? | 2016-06-14 | 2016-06-27 | 3FS+2w | 101.5d | 0d |  |  |  |
| 6 | 1.3.2 | Place Containers |  | 1d? | 2016-06-14 | 2016-06-14 | 5SS | 110.5d | 9d |  |  |  |
| 7 | 1.3.3 | Sort Debris |  | 1d? | 2016-06-28 | 2016-06-28 | 6, 5FF+1d | 101.5d | 0d |  |  |  |
| 8 | 1.3.4 | Haul Recycling |  | 1d? | 2016-07-05 | 2016-07-05 | 7 | 98.5d |  | start no earlier than 2016-07-05 |  |  |
| 9 | 1.3.5 | Haul Waste |  | 1d? | 2016-06-29 | 2016-06-29 | 7 | 101.5d |  |  |  |  |
| 10 | 1.4 | **Apply for Permits** |  | 0d | 2016-05-30 | 2016-05-30 |  | 0d |  |  |  |  |
| 11 | 1.4.1 | Secure foundation permit | milestone | 0d | 2016-05-30 | 2016-05-30 | 3 | 0d |  |  | General contractor |  |
| 12 | 1.4.2 | Secure framing permit | milestone | 0d | 2016-05-30 | 2016-05-30 | 3 | 0d |  |  | General contractor |  |
| 13 | 1.4.3 | Secure electrical permit | milestone | 0d | 2016-05-30 | 2016-05-30 | 3 | 0d |  |  | General contractor |  |
| 14 | 1.4.4 | Secure plumbing permit | milestone | 0d | 2016-05-30 | 2016-05-30 | 3 | 0d |  |  | General contractor |  |
| 15 | 1.4.5 | Secure HVAC permit | milestone | 0d | 2016-05-30 | 2016-05-30 | 3 | 0d |  |  | General contractor |  |
| 16 | 1.4.6 | Secure miscellaneous permits | milestone | 0d | 2016-05-30 | 2016-05-30 | 3 | 0d |  |  | General contractor |  |
| 17 | 2 | **Site Work** |  | 3d | 2016-05-31 | 2016-06-02 |  | 0d |  |  |  | 32h |
| 18 | 2.1 | Clear and grub lot |  | 1d | 2016-05-31 | 2016-05-31 | 11, 12, 13, 14, 16, 15 | 0d |  |  | Site excavation contractor | 8h |
| 19 | 2.2 | Install temporary power service |  | 1d | 2016-06-01 | 2016-06-01 | 18 | 0d |  |  | Electric company | 8h |
| 20 | 2.3 | Install underground utilities |  | 1d | 2016-06-02 | 2016-06-02 | 19 | 0d |  |  | Electric contractor; Plumbing contractor | 16h |
| 21 | 3 | **Foundation** |  | 41d | 2016-06-03 | 2016-08-01 |  | 0d |  |  |  | 280h |
| 22 | 3.1 | Excavate for foundations |  | 3d | 2016-06-03 | 2016-06-07 | 20 | 0d |  |  | Site excavation contractor | 24h |
| 23 | 3.2 | Form basement walls |  | 13d | 2016-06-08 | 2016-06-24 | 22 | 0d |  |  | Concrete contractor | 104h |
| 24 | 3.3 | Place concrete for foundations & basement walls |  | 12d | 2016-06-27 | 2016-07-12 | 23 | 0d |  |  | Concrete contractor | 96h |
| 25 | 3.4 | Cure basement walls for 7 days |  | 7d | 2016-07-13 | 2016-07-21 | 24 | 0d |  |  |  |  |
| 26 | 3.5 | Strip basement wall forms |  | 2d | 2016-07-22 | 2016-07-25 | 25 | 0d |  |  | Concrete contractor | 16h |
| 27 | 3.6 | Waterproof/insulate basement walls |  | 2d | 2016-07-26 | 2016-07-27 | 26 | 0d |  |  | Concrete contractor | 16h |
| 28 | 3.7 | Perform foundation inspection |  | 1d | 2016-07-28 | 2016-07-28 | 27, 22 | 0d |  |  | Inspector | 8h |
| 29 | 3.8 | Backfill foundation |  | 2d | 2016-07-29 | 2016-08-01 | 28 | 0d |  |  | Site excavation contractor | 16h |

| ID | WBS | Task | Duration | Start | Finish | Predecessors | Total slack | Free slack | Resources | Work |
| --- | --- | --- | --- | --- | --- | --- | --- | --- | --- | --- |
| 30 | 4 | **Framing** | 22d | 2016-08-02 | 2016-08-31 |  | 0d |  |  | 176h |
| 31 | 4.1 | Install 1st floor joists | 2d | 2016-08-02 | 2016-08-03 | 29 | 0d |  | Framing contractor | 16h |
| 32 | 4.2 | Lay 1st floor decking | 2d | 2016-08-04 | 2016-08-05 | 31 | 0d |  | Framing contractor | 16h |
| 33 | 4.3 | Frame 1st floor walls | 4d | 2016-08-08 | 2016-08-11 | 32 | 0d |  | Framing contractor | 32h |
| 34 | 4.4 | Frame 1st floor corners | 1d | 2016-08-12 | 2016-08-12 | 33 | 0d |  | Framing contractor | 8h |
| 35 | 4.5 | Install 2nd floor joists | 2d | 2016-08-15 | 2016-08-16 | 34 | 0d |  | Framing contractor | 16h |
| 36 | 4.6 | Frame 2nd floor decking | 2d | 2016-08-17 | 2016-08-18 | 35 | 0d |  | Framing contractor | 16h |
| 37 | 4.7 | Frame 2nd floor walls | 3d | 2016-08-19 | 2016-08-23 | 36 | 0d |  | Framing contractor | 24h |
| 38 | 4.8 | Frame 2nd floor corners | 2d | 2016-08-24 | 2016-08-25 | 37 | 0d |  | Framing contractor | 16h |
| 39 | 4.9 | Complete roof framing | 3d | 2016-08-26 | 2016-08-30 | 38 | 0d |  | Framing contractor | 24h |
| 40 | 4.10 | Conduct framing inspection | 1d | 2016-08-31 | 2016-08-31 | 39 | 0d |  | Inspector | 8h |
| 41 | 5 | **Dry In** | 21d | 2016-08-31 | 2016-09-29 |  | 0d |  |  | 152h |
| 42 | 5.1 | Install 1st floor sheathing | 3d | 2016-09-01 | 2016-09-05 | 40 | 0d |  | Framing contractor | 24h |
| 43 | 5.2 | Install 2nd floor sheathing | 3d | 2016-09-06 | 2016-09-08 | 42 | 0d |  | Framing contractor | 24h |
| 44 | 5.3 | Install roof decking | 3d | 2016-08-31 | 2016-09-02 | 39 | 3d | 0d | Framing contractor | 24h |
| 45 | 5.4 | Install felt, flashing and shingles | 3d | 2016-09-16 | 2016-09-20 | 53 | 0d |  | Roofing contractor | 24h |
| 46 | 5.5 | Hang 1st floor exterior doors | 1d | 2016-09-21 | 2016-09-21 | 45 | 0d |  | Framing contractor | 8h |
| 47 | 5.6 | Install 1st floor windows | 3d | 2016-09-22 | 2016-09-26 | 46 | 0d |  | Framing contractor | 24h |
| 48 | 5.7 | Install 2nd floor windows | 3d | 2016-09-27 | 2016-09-29 | 47 | 0d |  | Framing contractor | 24h |
| 49 | 6 | **Exterior Finishes** | 19d | 2016-09-30 | 2016-10-26 |  | 5d |  |  | 152h |
| 50 | 6.1 | Complete exterior brick | 16d | 2016-09-30 | 2016-10-21 | 48 | 5d | 0d | Masonry contractor | 128h |
| 51 | 6.2 | Complete exterior siding | 3d | 2016-10-24 | 2016-10-26 | 50 | 5d | 0d | Framing contractor | 24h |
| 52 | 7 | **Utility Rough-B97Ins and Complete Concrete** | 20d | 2016-09-05 | 2016-10-03 |  | 3d |  |  | 232h |
| 53 | 7.1 | Rough-in plumbing | 5d | 2016-09-09 | 2016-09-15 | 44, 43 | 0d |  | Plumbing contractor | 40h |
| 54 | 7.2 | Conduct rough-in plumbing inspection | 1d | 2016-09-16 | 2016-09-16 | 53 | 20d | 0d | Inspector | 8h |
| 55 | 7.3 | Place concrete for basement floor | 11d | 2016-09-19 | 2016-10-03 | 54 | 27.5d | 20d | Concrete contractor | 88h |
| 56 | 7.4 | Rough-in electrical | 5d | 2016-09-09 | 2016-09-15 | 44, 43 | 6d | 0d | Electric contractor | 40h |
| 57 | 7.5 | Conduct rough-in electrical inspection | 1d | 2016-09-16 | 2016-09-16 | 56 | 6d | 0d | Inspector | 8h |
| 58 | 7.6 | Rough-in HVAC | 3d | 2016-09-19 | 2016-09-21 | 57 | 6d | 0d | Heating and AC contractor | 24h |
| 59 | 7.7 | Conduct rough-in HVAC inspection | 1d | 2016-09-22 | 2016-09-22 | 58 | 24d |  | Inspector | 8h |
| 60 | 7.8 | Rough-in communication - phone, cable, computer, alarm | 2d | 2016-09-05 | 2016-09-06 | 44 | 16d |  | Electric contractor | 16h |

| ID | WBS | Task | Duration | Start | Finish | Predecessors | Total slack | Free slack | Resources | Work |
| --- | --- | --- | --- | --- | --- | --- | --- | --- | --- | --- |
| 61 | 8 | **Interior Finishes** | 29.5d | 2016-09-30 | 2016-11-10 |  | 0d |  |  | 408h |
| 62 | 8.1 | **Insulation** | 11d | 2016-09-30 | 2016-10-14 |  | 0d |  |  | 32h |
| 63 | 8.1.1 | Place wall insulation - 1st floor | 1d | 2016-09-30 | 2016-09-30 | 42, 48, 60, 58, 56, 43 | 0d |  | Insulation contractor | 8h |
| 64 | 8.1.2 | Place wall insulation - 2nd floor | 1d | 2016-10-03 | 2016-10-03 | 63 | 22d | 3d | Insulation contractor | 8h |
| 65 | 8.1.3 | Place ceiling insulation - 2nd floor | 1d | 2016-10-13 | 2016-10-13 | 71, 64 | 18.5d | 0d | Insulation contractor | 8h |
| 66 | 8.1.4 | Conduct insulation inspection | 1d | 2016-10-14 | 2016-10-14 | 65 | 18.5d | 11d | Inspector | 8h |
| 67 | 8.2 | **Drywall** | 9d | 2016-10-03 | 2016-10-13 |  | 0d |  |  | 80h |
| 68 | 8.2.1 | Install drywall - 1st floor walls | 2d | 2016-10-03 | 2016-10-04 | 63 | 0d |  | Drywall contractor | 16h |
| 69 | 8.2.2 | Install drywall - 1st floor overhead | 2d | 2016-10-05 | 2016-10-06 | 68 | 0d |  | Drywall contractor | 16h |
| 70 | 8.2.3 | Install drywall 2nd floor walls | 2d | 2016-10-07 | 2016-10-10 | 69, 64 | 19d | 0d | Drywall contractor | 16h |
| 71 | 8.2.4 | Install drywall 2nd floor overhead | 2d | 2016-10-11 | 2016-10-12 | 70 | 18.5d | 0d | Drywall contractor | 16h |
| 72 | 8.2.5 | Tape and float 1st floor drywall | 1d | 2016-10-07 | 2016-10-07 | 69 | 0d |  | Drywall contractor | 8h |
| 73 | 8.2.6 | Tape and float 2nd floor drywall | 1d | 2016-10-13 | 2016-10-13 | 71, 72 | 27.5d |  | Drywall contractor | 8h |
| 74 | 8.3 | **Paint and Wallpaper** | 17d | 2016-10-10 | 2016-11-01 |  | 0d |  |  | 72h |
| 75 | 8.3.1 | Texture all except entry and kitchen - 1st floor | 1d | 2016-10-10 | 2016-10-10 | 72 | 0d |  | Painting contractor | 8h |
| 76 | 8.3.2 | Paint all except entry and kitchen - 1st floor | 1d | 2016-10-11 | 2016-10-11 | 75 | 0d |  | Painting contractor | 8h |
| 77 | 8.3.3 | Hang wallpaper entry and kitchen - 1st floor | 1d | 2016-10-12 | 2016-10-12 | 76 | 0d |  | Painting contractor | 8h |
| 78 | 8.3.4 | Texture all - 2nd floor | 1d | 2016-10-11 | 2016-10-11 | 75 | 28.5d | 0d | Painting contractor | 8h |
| 79 | 8.3.5 | Paint all - 2nd floor | 1d | 2016-10-12 | 2016-10-12 | 78 | 28.5d |  | Painting contractor | 8h |
| 80 | 8.3.6 | Paint exterior siding & trim work | 4d | 2016-10-27 | 2016-11-01 | 51 | 4.5d | 0d | Painting contractor | 32h |
| 81 | 8.4 | **Cabinets** | 6d | 2016-10-13 | 2016-10-20 |  | 0d |  |  | 48h |
| 82 | 8.4.1 | Install 1st floor - kitchen cabinets | 2d | 2016-10-13 | 2016-10-14 | 77 | 0d |  | Finish carpentry contractor | 16h |
| 83 | 8.4.2 | Install 1st floor - master bath and guest cabinets | 1d | 2016-10-17 | 2016-10-17 | 82 | 0d |  | Finish carpentry contractor | 8h |
| 84 | 8.4.3 | Install 2nd floor - hall bath and private bath cabinets | 1d | 2016-10-18 | 2016-10-18 | 83 | 1d | 0d | Finish carpentry contractor | 8h |
| 85 | 8.4.4 | Install chair rails, crown moldings, trim | 2d | 2016-10-19 | 2016-10-20 | 84 | 14.5d | 7d | Finish carpentry contractor | 16h |

| ID | WBS | Task | Duration | Start | Finish | Predecessors | Total slack | Free slack | Resources | Work |
| --- | --- | --- | --- | --- | --- | --- | --- | --- | --- | --- |
| 86 | 8.5 | **Finish Plumbing** | 6d | 2016-10-17 | 2016-10-24 |  | 0d |  |  | 48h |
| 87 | 8.5.1 | Complete 1st floor - kitchen plumbing | 1d | 2016-10-17 | 2016-10-17 | 82, 54 | 0d |  | Plumbing contractor | 8h |
| 88 | 8.5.2 | Complete 1st floor - master bath and guest plumbing | 2d | 2016-10-18 | 2016-10-19 | 87, 83 | 0d |  | Plumbing contractor | 16h |
| 89 | 8.5.3 | Complete 2nd floor - hall bath and private bath plumbing | 2d | 2016-10-20 | 2016-10-21 | 88, 84 | 0d |  | Plumbing contractor | 16h |
| 90 | 8.5.4 | Conduct finish plumbing inspection | 1d | 2016-10-24 | 2016-10-24 | 89 | 0d |  | Inspector | 8h |
| 91 | 8.6 | **Finish Electrical** | 3d | 2016-10-24 | 2016-10-26 |  | 1d |  |  | 40h |
| 92 | 8.6.1 | Complete 1st floor circuits to service panel | 1d | 2016-10-24 | 2016-10-24 | 89, 57 | 3d | 0d | Electric contractor | 8h |
| 93 | 8.6.2 | Complete 2nd floor circuits to service panel | 1d | 2016-10-25 | 2016-10-25 | 92 | 3d | 0d | Electric contractor | 8h |
| 94 | 8.6.3 | Conduct finish electrical inspection | 1d | 2016-10-26 | 2016-10-26 | 93 | 3d |  | Inspector | 8h |
| 95 | 8.6.4 | Complete communications wiring - phone, cable, computer, alarm | 2d | 2016-10-25 | 2016-10-26 | 90 | 0d |  | Electric contractor | 16h |
| 96 | 8.7 | **Finish HVAC** | 3d | 2016-10-27 | 2016-10-31 |  | 0d |  |  | 24h |
| 97 | 8.7.1 | Complete 1st floor - zone 1 HVAC | 1d | 2016-10-27 | 2016-10-27 | 95, 59 | 0d |  | Heating and AC contractor | 8h |
| 98 | 8.7.2 | Complete 2nd floor - zone 2 HVAC | 1d | 2016-10-28 | 2016-10-28 | 97 | 0d |  | Heating and AC contractor | 8h |
| 99 | 8.7.3 | Conduct HVAC inspection | 1d | 2016-10-31 | 2016-10-31 | 98 | 0d |  | Inspector | 8h |
| 100 | 8.8 | **Carpet, Tile and Appliances** | 7.5d | 2016-11-01 | 2016-11-10 |  | 0d |  |  | 64h |
| 101 | 8.8.1 | Tile entry, kitchen and baths | 3d | 2016-11-01 | 2016-11-03 | 94, 99 | 0d |  | Flooring contractor | 24h |
| 102 | 8.8.2 | Carpet 1st floor | 2d | 2016-11-04 | 2016-11-07 | 101 | 0d |  | Flooring contractor | 16h |
| 103 | 8.8.3 | Carpet 2nd floor | 2d | 2016-11-08 | 2016-11-09 | 102 | 0d |  | Flooring contractor | 16h |
| 104 | 8.8.4 | Install appliances | 1d | 2016-11-10 | 2016-11-10 | 103 | 0d |  | Appliance contractor | 8h |
| 105 | 9 | **Landscaping and Grounds Work** | 14.5d? | 2016-11-02 | 2016-11-22 |  | 0d |  |  | 32h |
| 106 | 9.1 | Pour concrete driveway and sidewalks | 2d | 2016-11-02 | 2016-11-03 | 80 | 4.5d |  | Concrete contractor | 16h |
| 107 | 9.2 | Install backyard fence | 2d | 2016-11-11 | 2016-11-14 | 104, 106 | 0d |  | Fencing contractor | 16h |
| 108 | 9.3 | Order Plants and Trees | 1d? | 2016-11-15 | 2016-11-15 | 107 | 0d |  |  |  |
| 109 | 9.4 | Build Compost Bin | 1d? | 2016-11-16 | 2016-11-16 | 108 | 0d |  |  |  |
| 110 | 9.5 | Build Flower Beds and Edges | 1d? | 2016-11-17 | 2016-11-17 | 109 | 0d |  |  |  |
| 111 | 9.6 | Weed and Trim Existing Yard | 1d? | 2016-11-18 | 2016-11-18 | 110 | 0d |  |  |  |
| 112 | 9.7 | Plant New Plants and Trees | 1d? | 2016-11-21 | 2016-11-21 | 111 | 0d |  |  |  |
| 113 | 9.8 | Re-Seed Bare Lawn Areas | 1d? | 2016-11-22 | 2016-11-22 | 112 | 0d |  |  |  |

Notes:
- 105: Additional tasks provided by Gary Clark.

| ID | WBS | Task | Type | Duration | Start | Finish | Predecessors | Total slack | Free slack | Deadline | Resources | Work |
| --- | --- | --- | --- | --- | --- | --- | --- | --- | --- | --- | --- | --- |
| 114 | 10 | **Final Acceptance** |  | 14.5d | 2016-11-01 | 2016-11-21 |  | 1d |  |  |  | 64h |
| 115 | 10.1 | Complete final inspection for certificate of occupancy |  | 1d | 2016-11-01 | 2016-11-01 | 99, 94, 90, 66, 85, 55 | 7.5d | 6.5d |  | Inspector | 8h |
| 116 | 10.2 | Cleanup for occupancy |  | 1d | 2016-11-11 | 2016-11-11 | 104, 115 | 1d | 0d |  | Maid service | 8h |
| 117 | 10.3 | Perform final walk-through inspection |  | 1d | 2016-11-14 | 2016-11-14 | 116 | 1d | 0d |  | Owner | 8h |
| 118 | 10.4 | Complete punch list items |  | 5d | 2016-11-15 | 2016-11-21 | 117 | 1d | 0d |  | General contractor | 40h |
| 119 | 10.5 | Ready for Move-In | milestone | 0d | 2016-11-21 | 2016-11-21 | 118 | 1d |  | 2016-12-31 |  |  |
